# PCServis

How a schedule from MS Project changed from version to version. A marks actual dates.

## Version 1 (saved 2012-11-15, file PCServis.mpp)

| ID | WBS | Task | Duration | Start | Finish | Predecessors | Total float | Constraint |
| --- | --- | --- | --- | --- | --- | --- | --- | --- |
| 1 | 1 | **Startup** | 26d? | 2012-11-15 | 2012-12-20 |  | 0d |  |
| 2 | 1.1 | **Tvorba hypotézy** | 5d | 2012-11-15 | 2012-11-21 |  | 0d |  |
| 3 |  | Minimální životaschopný produkt | 2d | 2012-11-15 | 2012-11-16 |  | 0d |  |
| 4 |  | Určení konkurentů | 1d | 2012-11-19 | 2012-11-19 | 3 | 23d |  |
| 5 |  | Výpočet trhu a určení typu | 2d | 2012-11-19 | 2012-11-20 | 3 | 0d |  |
| 6 |  | Týdenní aktualizace | 1d | 2012-11-21 | 2012-11-21 | 5 | 0d |  |
| 7 | 1.2 | **Návrh prodeje** | 7d | 2012-11-22 | 2012-11-30 | 6 | 0d |  |
| 8 |  | Návrh textu | 1d | 2012-11-22 | 2012-11-22 |  | 0d |  |
| 9 |  | Testování textu | 4d | 2012-11-23 | 2012-11-28 | 8 | 0d |  |
| 10 |  | Opakování návrhu textu | 2d | 2012-11-29 | 2012-11-30 | 9 | 0d |  |
| 11 | 1.3 | **Logistika webové stránky** | 2d | 2012-12-03 | 2012-12-04 | 10 | 0d |  |
| 12 |  | Získání jména | 1d | 2012-12-03 | 2012-12-03 |  | 0d |  |
| 13 |  | Využití třetích stran pro tvorbu webu | 1d | 2012-12-04 | 2012-12-04 | 12 | 0d |  |
| 14 | 1.4 | **Vytvoření minimálně životaschopného webu** | 6d | 2012-12-05 | 2012-12-12 | 13 | 0d |  |
| 15 |  | Návrh designu | 2d | 2012-12-05 | 2012-12-06 |  | 10d |  |
| 16 |  | Návrh funkcionalit | 6d | 2012-12-05 | 2012-12-12 |  | 0d |  |
| 17 | 1.5 | **Práce se zákazníky** | 6d? | 2012-12-13 | 2012-12-20 | 16 | 0d |  |
| 18 |  | Pozvání zákazníků | 3d | 2012-12-13 | 2012-12-17 |  | 0d |  |
| 19 |  | Zpětná odezva | 3d | 2012-12-18 | 2012-12-20 | 18 | 0d |  |
| 20 |  | Prezentace | 1d? | 2012-12-20 | 2012-12-20 |  | 0d | start no earlier than 2012-12-20 |

## Version 2 (saved 2012-11-29, file harmonogram2.mpp)

Last finish stays 2012-12-20. Complete tasks 0 → 6.

Changed:

| ID | Task | Start | Finish | Duration | Complete | Total float | Predecessors | Other |
| --- | --- | --- | --- | --- | --- | --- | --- | --- |
| 1 | **Startup** | 2012-11-15 A |  |  | 0% → 45% |  |  |  |
| 2 | **Tvorba hypotézy** | 2012-11-15 A | 2012-11-21 A |  | 0% → 100% | 0d → none |  |  |
| 3 | Minimální životaschopný produkt | 2012-11-15 A | 2012-11-16 A |  | 0% → 100% | 0d → none |  |  |
| 4 | Určení konkurentů | 2012-11-19 A | 2012-11-19 A |  | 0% → 100% | 23d → none |  |  |
| 5 | Výpočet trhu a určení typu | 2012-11-19 A | 2012-11-20 A |  | 0% → 100% | 0d → none |  |  |
| 6 | Týdenní aktualizace | 2012-11-21 A | 2012-11-21 A |  | 0% → 100% | 0d → none | 5 → 5, 4 |  |
| 7 | **Návrh prodeje** | 2012-11-22 A | 2012-11-30 → 2012-11-29 (-1d) | 7d → 6d | 0% → 17% | 0d → 15d | 6 → none |  |
| 8 | Návrh textu | 2012-11-22 A | 2012-11-22 A |  | 0% → 100% | 0d → none | none → 6 |  |
| 9 | Testování textu |  | 2012-11-28 → 2012-11-27 (-1d) | 4d → 3d |  | 0d → 15d |  |  |
| 10 | Opakování návrhu textu | 2012-11-29 → 2012-11-28 (-1d) | 2012-11-30 → 2012-11-29 (-1d) |  |  | 0d → 15d |  |  |
| 11 | **Logistika webové stránky** | 2012-12-03 → 2012-11-21 A (-12d) | 2012-12-04 → 2012-11-28 (-6d) | 2d → 4.67d | 0% → 77% | 0d → 7.31d | 10 → none |  |
| 12 | Získání jména | 2012-12-03 → 2012-11-21 A (-12d) | 2012-12-03 → 2012-11-23 A (-10d) | 1d → 2d | 0% → 100% | 0d → none | none → 6 | resources Ondřej Polák; Ladislav Šťástka → Ondřej Polák; Ladislav Šťástka [50%] |
| 13 | Využití třetích stran pro tvorbu webu | 2012-12-04 → 2012-11-26 A (-8d) | 2012-12-04 → 2012-11-28 (-6d) | 1d → 2.67d | 0% → 60% | 0d → 7.31d |  | resources Ondřej Polák; Ladislav Šťástka → Ladislav Šťástka [50%]; Ondřej Polák [50%] |
| 14 | **Vytvoření minimálně životaschopného webu** | 2012-12-05 → 2012-11-28 A (-7d) | 2012-12-12 → 2012-12-06 (-6d) | 6d → 5.5d | 0% → 45% | 0d → 4.83d | 13 → none |  |
| 15 | Návrh designu | 2012-12-05 → 2012-11-28 A (-7d) | 2012-12-06 → 2012-11-30 (-6d) |  | 0% → 45% | 10d → 6.41d | none → 13 |  |
| 16 | Návrh funkcionalit | 2012-12-05 → 2012-11-30 A (-5d) | 2012-12-12 → 2012-12-06 (-6d) | 6d → 3.5d | 0% → 45% | 0d → 4.83d | none → 15 |  |
| 17 | **Práce se zákazníky** | 2012-12-13 → 2012-12-06 (-7d) |  | 6d? → 10.83d? |  |  | 16 → none |  |
| 18 | Pozvání zákazníků | 2012-12-13 → 2012-12-06 (-7d) | 2012-12-17 → 2012-12-11 (-6d) |  |  | 0d → 4.83d | none → 16 |  |
| 19 | Zpětná odezva | 2012-12-18 → 2012-12-11 (-7d) | 2012-12-20 → 2012-12-14 (-6d) |  |  | 0d → 4.83d |  |  |

## Version 3 (saved 2012-12-06, file harmonogram3.mpp)

Last finish stays 2012-12-20. Complete tasks 6 → 9.

Changed:

| ID | Task | Start | Finish | Complete | Total float | Predecessors |
| --- | --- | --- | --- | --- | --- | --- |
| 1 | **Startup** |  |  | 45% → 65% |  |  |
| 7 | **Návrh prodeje** |  |  | 17% → 47% | 15d → 9d |  |
| 9 | Testování textu | 2012-11-23 A |  | 0% → 60% |  |  |
| 11 | **Logistika webové stránky** |  | 2012-11-28 A | 77% → 100% | 7.31d → none |  |
| 13 | Využití třetích stran pro tvorbu webu |  | 2012-11-28 A | 60% → 100% | 7.31d → none |  |
| 14 | **Vytvoření minimálně životaschopného webu** |  | 2012-12-06 A | 45% → 100% | 4.83d → none |  |
| 15 | Návrh designu |  | 2012-11-30 A | 45% → 100% | 6.41d → none |  |
| 16 | Návrh funkcionalit |  | 2012-12-06 A | 45% → 100% | 4.83d → none |  |
| 18 | Pozvání zákazníků |  |  |  |  | 16 → 16, 10 |

## Version 4 (saved 2012-12-13, file harmonogram4.mpp)

Last finish stays 2012-12-20. Complete tasks 9 → 11.

Changed:

| ID | Task | Start | Finish | Complete | Total float |
| --- | --- | --- | --- | --- | --- |
| 1 | **Startup** |  |  | 65% → 81% |  |
| 7 | **Návrh prodeje** |  | 2012-11-29 A | 47% → 100% | 9d → none |
| 9 | Testování textu |  | 2012-11-27 A | 60% → 100% | 15d → none |
| 10 | Opakování návrhu textu | 2012-11-28 A | 2012-11-29 A | 0% → 100% | 9d → none |
| 17 | **Práce se zákazníky** | 2012-12-06 A |  | 0% → 21% |  |
| 18 | Pozvání zákazníků | 2012-12-06 A |  | 0% → 50% |  |
